# OT1 : Controleur

Schedule from GanttProject, 2008-01-07 to 2008-05-30.
Lycée Louis Couffignal
Etudiant 1

## Calendars

- Project calendar: Mon-Fri working; Sat-Sun off. Exceptions (off unless hours are given): 2008-02-11 to 2008-02-16, 2008-02-18 to 2008-02-23, 2008-04-07 to 2008-04-12, 2008-04-14 to 2008-04-19, 2008-05-01.

## Schedule

| ID | WBS | Task | Duration | Start | Finish | Predecessors | Tache |
| --- | --- | --- | --- | --- | --- | --- | --- |
| 1 | 1 | **Fonction auxiliaire d'alimentation et fonction FP4 : "Horloge autonome"** | 84d | 2008-01-07 | 2008-05-30 |  |  |
| 2 | 1.1 | Appropriation du dossier | 15d | 2008-01-07 | 2008-01-25 |  | T1 |
| 3 | 1.2 | **Modes LPM du MSP430** | 5d | 2008-01-21 | 2008-01-25 |  |  |
| 4 | 1.2.1 | Validation par émulation | 5d | 2008-01-21 | 2008-01-25 |  | T2 |
| 5 | 1.3 | Rédaction du rapport d'étude | 15d | 2008-01-07 | 2008-01-25 |  | T3 |
| 6 | 1.4 | RV1 | 5d | 2008-01-28 | 2008-02-01 | 2, 4, 5 | RV1 |
| 7 | 1.5 | Production du dossier de fabrication | 15d | 2008-02-04 | 2008-03-07 | 6 | T4 |
| 8 | 1.6 | Choix du MSP430 (en équipe) et des composants de l'alimentation | 35d | 2008-01-07 | 2008-03-07 |  | T5 |
| 9 | 1.7 | RV2 | 5d | 2008-03-10 | 2008-03-14 | 7, 8 | RV2 |
| 10 | 1.8 | Réalisation carte de câblage imprimé | 5d | 2008-03-17 | 2008-03-21 | 9 | T6 |
| 11 | 1.9 | câblage de la maquette | 10d | 2008-03-24 | 2008-04-04 | 10 | T7 |
| 12 | 1.10 | Proposition des procédures de test | 15d | 2008-03-17 | 2008-04-04 | 9 | T8 |
| 13 | 1.11 | RV3 | 5d | 2008-04-21 | 2008-04-25 | 11, 12 | RV3 |
| 14 | 1.12 | Tests des fonctions sur la maquette | 14d | 2008-04-28 | 2008-05-16 | 13 | T9 |
| 15 | 1.13 | Rédiger le rapport de tests | 14d | 2008-04-28 | 2008-05-16 | 13 | T11 |
| 16 | 1.14 | Constituer le dossier technique de projet | 10d | 2008-05-19 | 2008-05-30 | 14, 15 | T12 |
